# Moncton Move

Schedule from MS Project, 2007-03-21 to 2007-03-31.
Purolator Courier

## Calendars

- Standard: Mon-Fri 08:00-12:00, 13:00-17:00; Sat-Sun off. Exceptions (off unless hours are given): 2007-03-24 to 2007-03-25 08:00-12:00, 13:00-17:00, 2007-03-31 to 2007-04-01 08:00-12:00, 13:00-17:00.

## Resources

| Resource |
| --- |
| Mettler |
| PCL/MHE |

## Schedule

| ID | WBS | Task | Duration | Start | Finish | Predecessors | Total slack | Free slack | Constraint | Resources | Work |
| --- | --- | --- | --- | --- | --- | --- | --- | --- | --- | --- | --- |
| 1 | 1 | **Moncton Scanner Upgrade** | 10.8d | 2007-03-21 08:00 | 2007-03-31 15:24 |  | 0d |  |  |  | 68h |
| 2 | 1.1 | **Equipment** | 1d | 2007-03-21 08:00 | 2007-03-21 17:00 |  | 6d | 1d |  |  | 16h |
| 3 | 1.1.1 | Equipment Arrival | 1d | 2007-03-21 08:00 | 2007-03-21 17:00 |  | 6d |  | start no earlier than 2007-03-21 08:00 | Mettler | 8h |
| 4 | 1.1.2 | Equipment Audit | 1d | 2007-03-21 08:00 | 2007-03-21 17:00 |  | 6d |  | start no earlier than 2007-03-21 08:00 | Mettler | 8h |
| 5 | 1.2 | **Stage 1 Scanner Upgrade 201** | 2.6d | 2007-03-23 08:00 | 2007-03-25 13:48 | 2 | 4.3d | 1.4d |  |  | 22.4h |
| 6 | 1.2.1 | Remove All DS8100s and Wiring | 0.2d | 2007-03-23 08:00 | 2007-03-23 09:36 |  | 5d | 0d | start no earlier than 2007-03-23 08:00 | Mettler | 1.6h |
| 7 | 1.2.2 | Shorten Tunnel | 0.2d | 2007-03-23 09:36 | 2007-03-23 11:12 | 6 | 7.1d |  | start no earlier than 2007-03-23 08:00 | Mettler | 1.6h |
| 8 | 1.2.3 | Reposition Subframe | 0.2d | 2007-03-23 09:36 | 2007-03-23 11:12 | 6 | 5d | 0d | start no earlier than 2007-03-23 08:00 | PCL/MHE | 1.6h |
| 9 | 1.2.4 | **Rebuild Tunnel** | 1.1d | 2007-03-23 11:12 | 2007-03-24 12:00 | 8 | 4.3d |  |  |  | 8.8h |
| 10 | 1.2.4.1 | ReBuild Bosch Frame Tunnel | 0.3d | 2007-03-23 11:12 | 2007-03-23 14:36 |  | 4.3d | 0d |  | Mettler | 2.4h |
| 11 | 1.2.4.2 | Install DS8100a DX8200as | 0.4d | 2007-03-23 14:36 | 2007-03-24 08:48 | 10 | 4.3d | 0d |  | Mettler | 3.2h |
| 12 | 1.2.4.3 | Wiring | 0.4d | 2007-03-24 08:48 | 2007-03-24 12:00 | 11 | 4.3d | 0d | start no earlier than 2007-03-17 08:00 | Mettler | 3.2h |
| 13 | 1.2.5 | Pack Track | 0.6d | 2007-03-24 13:00 | 2007-03-25 08:48 | 12 | 4.3d | 0d |  | Mettler | 4.8h |
| 14 | 1.2.6 | Merge Calibration | 0.4d | 2007-03-25 08:48 | 2007-03-25 12:00 | 13 | 4.3d | 0d |  | Mettler | 3.2h |
| 15 | 1.2.7 | Testing | 0.1d | 2007-03-25 13:00 | 2007-03-25 13:48 | 14 | 4.3d |  |  | Mettler | 0.8h |
| 16 | 1.3 | **Stage 2 Scanner Upgrade 202 (Incline)** | 1.9d | 2007-03-27 08:00 | 2007-03-28 16:12 | 5 | 2.9d |  |  |  | 15.2h |
| 17 | 1.3.1 | Add additional bosch framing to the tunnel | 0.3d | 2007-03-27 08:00 | 2007-03-27 10:24 |  | 2.9d | 0d | start no earlier than 2007-03-27 08:00 | Mettler | 2.4h |
| 18 | 1.3.2 | Add additional scanners | 0.3d | 2007-03-27 10:24 | 2007-03-27 13:48 | 17 | 2.9d | 0d |  | Mettler | 2.4h |
| 19 | 1.3.3 | Add SC8000 and wire tunnel | 0.3d | 2007-03-27 13:48 | 2007-03-27 16:12 | 18 | 2.9d | 0d |  | Mettler | 2.4h |
| 20 | 1.3.4 | Pack Trak added Scanners | 0.4d | 2007-03-27 16:12 | 2007-03-28 10:24 | 19 | 2.9d | 0d |  | Mettler | 3.2h |
| 21 | 1.3.5 | Merge and Pack Trak Added Scanners | 0.3d | 2007-03-28 10:24 | 2007-03-28 13:48 | 20 | 2.9d | 0d |  | Mettler | 2.4h |
| 22 | 1.3.6 | Test | 0.3d | 2007-03-28 13:48 | 2007-03-28 16:12 | 21 | 2.9d |  |  | Mettler | 2.4h |
| 23 | 1.4 | **Stage 3 Dimensioner Move** | 1.8d | 2007-03-30 08:00 | 2007-03-31 15:24 |  | 0d |  |  |  | 14.4h |
| 24 | 1.4.1 | Remove Dimensioner and Framing | 0.3d | 2007-03-30 08:00 | 2007-03-30 10:24 |  | 0d |  | start no earlier than 2007-03-30 08:00 | Mettler | 2.4h |
| 25 | 1.4.2 | Reposition DimensionerSubframe | 0.3d | 2007-03-30 10:24 | 2007-03-30 13:48 | 24 | 0d |  | start no earlier than 2007-03-23 08:00 | PCL/MHE | 2.4h |
| 26 | 1.4.3 | ReInstall Dimensioner Frame | 0.3d | 2007-03-30 13:48 | 2007-03-30 16:12 | 25 | 0d |  |  | Mettler | 2.4h |
| 27 | 1.4.4 | ReInstall Barn | 0.3d | 2007-03-30 16:12 | 2007-03-31 09:36 | 26 | 0d |  |  | Mettler | 2.4h |
| 28 | 1.4.5 | Calibrate Dimensioner | 0.3d | 2007-03-31 09:36 | 2007-03-31 12:00 | 27 | 0d |  |  | Mettler | 2.4h |
| 29 | 1.4.6 | Test | 0.3d | 2007-03-31 13:00 | 2007-03-31 15:24 | 28 | 0d |  |  | Mettler | 2.4h |

Notes:
- 4: The installation will not occur unless all equipment necessary is accounted for.
- 8: Involves detaching the subframe and rewelding to shorten scanner tunnel
- 25: Involves detaching the subframe and rewelding to shorten scanner tunnel
